Schedule from MS Project, 2007-02-09 to 2007-03-20, 7 hours a day.
Nancy Matis SPRL

## Calendars

- Standard: Mon-Fri 09:00-12:00, 14:00-18:00; Sat-Sun off.

## Resources

| Resource |
| --- |
| Translators |
| Revisors |
| Ling QA |
| DTP person |
| Art specialist |
| PM |
| Client |
| Rreviewer |
| Reviewer |

## Schedule

| ID | WBS | Task | Duration | Start | Finish | Predecessors | Total slack | Free slack | Resources | Work |
| --- | --- | --- | --- | --- | --- | --- | --- | --- | --- | --- |
| 1 | 1 | **Whole project per team** | 26.9d | 2007-02-09 | 2007-03-19 |  | 0d |  |  | 515.55h |
| 2 | 1.1 | Analysis of the project | 1d | 2007-02-09 | 2007-02-09 |  | 0d |  | PM | 7h |
| 3 | 1.2 | **Documentation** | 25.9d | 2007-02-12 | 2007-03-19 |  | 0d |  |  | 318.15h |
| 4 | 1.2.1 | Translation | 10.2d | 2007-02-12 | 2007-02-26 | 2 | 0d |  | Translators [200%] | 142.8h |
| 5 | 1.2.2 | Revision | 10.2d | 2007-02-14 | 2007-02-28 | 4FS-8d | 0d |  | Revisors | 71.4h |
| 6 | 1.2.3 | Reviewing | 3.4d | 2007-02-28 | 2007-03-05 | 5 | 0d |  | Reviewer | 23.8h |
| 7 | 1.2.4 | CLIENT REVIEW | 4d | 2007-03-05 | 2007-03-09 | 6 | 0d |  | Client | 28h |
| 8 | 1.2.5 | Insertion of feedback | 3d | 2007-03-09 | 2007-03-14 | 7 | 0d |  | Reviewer | 21h |
| 9 | 1.2.6 | Screenshot | 1.35d | 2007-02-28 | 2007-03-01 | 6SS | 13.15d |  | Art specialist | 9.45h |
| 10 | 1.2.7 | DTP | 2.6d | 2007-03-14 | 2007-03-19 | 8 | 0d |  | DTP person | 18.2h |
| 11 | 1.2.8 | DTP QA | 0.5d | 2007-03-19 | 2007-03-19 | 10 | 0d |  | Reviewer | 3.5h |
| 12 | 1.3 | **Help** | 16.1d | 2007-02-12 | 2007-03-06 |  | 10.8d |  |  | 190.4h |
| 13 | 1.3.1 | Translation | 6.5d | 2007-02-12 | 2007-02-20 | 2 | 10.8d | 0d | Translators [200%] | 91h |
| 14 | 1.3.2 | Revision | 6.5d | 2007-02-14 | 2007-02-22 | 13FS-4d | 10.8d | 0d | Revisors | 45.5h |
| 15 | 1.3.3 | Reviewing | 2.1d | 2007-02-23 | 2007-02-27 | 14 | 10.8d | 0d | Reviewer | 14.7h |
| 16 | 1.3.4 | CLIENT REVIEW | 3d | 2007-02-27 | 2007-03-02 | 15 | 10.8d | 0d | Client | 21h |
| 17 | 1.3.5 | Insertion of feedback | 2d | 2007-03-02 | 2007-03-06 | 16 | 10.8d |  | Reviewer | 14h |
| 18 | 1.3.6 | Screenshot | 0.6d | 2007-02-23 | 2007-02-23 | 15SS | 17.3d |  | Art specialist | 4.2h |
| 19 | 2 | Project delivery | 1d | 2007-03-19 | 2007-03-20 | 11 | 0d |  | PM | 7h |
